# V520 - výměna vedení

Schedule from MS Project, 2018-08-09 to 2019-05-28, A marks actual dates.

## Calendars

- 10 denni cyklus: Mon-Fri 08:00-12:00, 13:00-17:00; Sat-Sun off. Exceptions (off unless hours are given): 2018-08-11 to 2026-04-05 08:00-12:00, 13:00-17:00 (pracovna nedela, recurring), 2018-08-18 to 2026-04-04 08:00-12:00, 13:00-17:00 (Pracovna sobota, recurring), 2018-08-23 to 2022-06-10 (Volny stvrtok, piatok, recurring).

## Schedule

| ID | WBS | Task | Duration | Start | Finish | Predecessors | Total slack | Free slack |
| --- | --- | --- | --- | --- | --- | --- | --- | --- |
| 1 | 1 | Zařízení staveniště | 2d | 2018-08-09 | 2018-08-10 |  | 1d | 0d |
| 2 | 2 | **Demontážní práce** | 35d | 2018-08-13 | 2018-09-28 |  | 1d | 0d |
| 3 | 2.1 | **portál Jihlava - p.b.2** | 3d | 2018-08-13 | 2018-08-15 |  | 1d |  |
| 4 | 2.1.1 | Demontáž vodičů | 1d | 2018-08-13 | 2018-08-13 | 1 | 1d | 0d |
| 5 | 2.1.2 | Demontáž stožárů a základů | 2d | 2018-08-14 | 2018-08-15 | 4 | 1d | 0d |
| 6 | 2.2 | **p.b.2 - p.b. 16** | 5d | 2018-08-16 | 2018-08-20 |  | 1d |  |
| 7 | 2.2.1 | Demontáž vodičů | 2d | 2018-08-16 | 2018-08-17 | 5 | 1d | 0d |
| 8 | 2.2.2 | Demontáž stožárů a základů | 3d | 2018-08-18 | 2018-08-20 | 7 | 1d | 0d |
| 9 | 2.3 | **p.b.16 - p.b.30** | 5d | 2018-08-21 | 2018-08-29 |  | 1d |  |
| 10 | 2.3.1 | Demontáž vodičů | 2d | 2018-08-21 | 2018-08-22 | 8 | 1d | 0d |
| 11 | 2.3.2 | Demontáž stožárů a základů | 3d | 2018-08-27 | 2018-08-29 | 10 | 1d | 0d |
| 12 | 2.4 | **p.b.30 - p.b.46** | 5d | 2018-08-30 | 2018-09-03 |  | 1d |  |
| 13 | 2.4.1 | Demontáž vodičů | 2d | 2018-08-30 | 2018-08-31 | 11 | 1d | 0d |
| 14 | 2.4.2 | Demontáž stožárů a základů | 3d | 2018-09-01 | 2018-09-03 | 13 | 1d | 0d |
| 15 | 2.5 | **p.b.46 - p.b.57** | 4d | 2018-09-04 | 2018-09-11 |  | 1d |  |
| 16 | 2.5.1 | Demontáž vodičů | 1d | 2018-09-04 | 2018-09-04 | 14 | 1d | 0d |
| 17 | 2.5.2 | Demontáž stožárů a základů | 3d | 2018-09-05 | 2018-09-11 | 16 | 1d | 0d |
| 18 | 2.6 | **p.b.57 - p.b.61** | 3d | 2018-09-12 | 2018-09-14 |  | 1d |  |
| 19 | 2.6.1 | Demontáž vodičů | 1d | 2018-09-12 | 2018-09-12 | 17 | 1d | 0d |
| 20 | 2.6.2 | Demontáž stožárů a základů | 2d | 2018-09-13 | 2018-09-14 | 19 | 1d | 0d |
| 21 | 2.7 | **p.b.61 - p.b.74** | 5d | 2018-09-15 | 2018-09-19 |  | 1d |  |
| 22 | 2.7.1 | Demontáž vodičů | 2d | 2018-09-15 | 2018-09-16 | 20 | 1d | 0d |
| 23 | 2.7.2 | Demontáž stožárů a základů | 3d | 2018-09-17 | 2018-09-19 | 22 | 1d | 0d |
| 24 | 2.8 | **p.b.74 - p.b.88** | 5d | 2018-09-24 | 2018-09-28 |  | 1d |  |
| 25 | 2.8.1 | Demontáž vodičů | 2d | 2018-09-24 | 2018-09-25 | 23 | 1d | 0d |
| 26 | 2.8.2 | Demontáž stožárů a základů | 3d | 2018-09-26 | 2018-09-28 | 25 | 1d |  |

| ID | WBS | Task | Duration | Start | Finish | Predecessors | Total slack | Free slack | Constraint |
| --- | --- | --- | --- | --- | --- | --- | --- | --- | --- |
| 27 | 2.9 | **p.b.88 - p.b.104** | 5d | 2018-08-13 | 2018-08-17 |  | 1d |  |  |
| 28 | 2.9.1 | Demontáž vodičů | 2d | 2018-08-13 | 2018-08-14 | 1 | 1d | 0d |  |
| 29 | 2.9.2 | Demontáž stožárů a základů | 3d | 2018-08-15 | 2018-08-17 | 28 | 1d | 0d |  |
| 30 | 2.10 | **p.b.104 - p.b.130** | 8d | 2018-08-18 | 2018-08-29 |  | 1d |  |  |
| 31 | 2.10.1 | Demontáž vodičů | 3d | 2018-08-18 | 2018-08-20 | 29 | 1d | 0d |  |
| 32 | 2.10.2 | Demontáž stožárů a základů | 5d | 2018-08-21 | 2018-08-29 | 31 | 1d | 0d |  |
| 33 | 2.11 | **p.b.130 - p.b.153** | 8d | 2018-08-30 | 2018-09-10 |  | 1d |  |  |
| 34 | 2.11.1 | Demontáž vodičů | 3d | 2018-08-30 | 2018-09-01 | 32 | 1d | 0d |  |
| 35 | 2.11.2 | Demontáž stožárů a základů | 5d | 2018-09-02 | 2018-09-10 | 34 | 1d | 0d |  |
| 36 | 2.12 | **p.b.153 - p.b.163** | 4d | 2018-09-11 | 2018-09-14 |  | 1d |  |  |
| 37 | 2.12.1 | Demontáž vodičů | 1d | 2018-09-11 | 2018-09-11 | 35 | 1d | 0d |  |
| 38 | 2.12.2 | Demontáž stožárů a základů | 3d | 2018-09-12 | 2018-09-14 | 37 | 1d | 0d |  |
| 39 | 2.13 | **p.b.163 - p.b.173** | 4d | 2018-09-15 | 2018-09-18 |  | 1d |  |  |
| 40 | 2.13.1 | Demontáž vodičů | 1d | 2018-09-15 | 2018-09-15 | 38 | 1d | 0d |  |
| 41 | 2.13.2 | Demontáž stožárů a základů | 3d | 2018-09-16 | 2018-09-18 | 40 | 1d | 0d |  |
| 42 | 2.14 | **p.b.173 - p.b.184** | 5d | 2018-09-19 | 2018-09-27 |  | 1d |  |  |
| 43 | 2.14.1 | Demontáž vodičů | 2d | 2018-09-19 | 2018-09-24 | 41 | 1d | 0d |  |
| 44 | 2.14.2 | Demontáž stožárů a základů | 3d | 2018-09-25 | 2018-09-27 | 43 | 1d | 0d |  |
| 45 | 2.15 | **p.b.184 - portál Telč** | 1d | 2018-09-28 | 2018-09-28 |  | 1d | 0d |  |
| 46 | 2.15.1 | Demontáž vodičů | 1d | 2018-09-28 | 2018-09-28 | 44 | 1d |  |  |
| 47 | 3 | **Montážní práce základů a stožárů** | 137d | 2018-09-29 | 2019-04-09 | 2 | 1d |  |  |
| 48 | 3.1 | **p.b.1 - p.b.7** | 40d | 2018-09-29 | 2018-11-23 |  | 1d |  |  |
| 49 | 3.1.1 | Realizace základů | 8d | 2018-09-29 | 2018-10-10 |  | 1d | 0d |  |
| 50 | 3.1.2 | Montáž OK na zemi | 8d | 2018-10-29 | 2018-11-09 |  | 7d | 0d | start no earlier than 2018-10-29 |
| 51 | 3.1.3 | Postavení OK | 4d | 2018-11-20 | 2018-11-23 | 49FS+28d, 50 | 46d | 6d |  |

| ID | WBS | Task | Duration | Start | Finish | Predecessors | Total slack | Free slack |
| --- | --- | --- | --- | --- | --- | --- | --- | --- |
| 52 | 3.2 | **p.b.8 - p.b.16** | 43d | 2018-10-11 | 2018-12-08 |  | 1d |  |
| 53 | 3.2.1 | Realizace základů | 10d | 2018-10-11 | 2018-10-24 | 49 | 1d | 0d |
| 54 | 3.2.2 | Montáž OK na zemi | 10d | 2018-11-10 | 2018-11-23 | 50 | 7d | 0d |
| 55 | 3.2.3 | Postavení OK | 5d | 2018-12-04 | 2018-12-08 | 53FS+28d, 54, 51 | 40d | 4d |
| 56 | 3.3 | **p.b.17 - p.b.23** | 42d | 2018-10-25 | 2018-12-21 |  | 1d |  |
| 57 | 3.3.1 | Realizace základů | 9d | 2018-10-25 | 2018-11-06 | 53 | 1d | 0d |
| 58 | 3.3.2 | Montáž OK na zemi | 9d | 2018-11-24 | 2018-12-06 | 54 | 7d | 0d |
| 59 | 3.3.3 | Postavení OK | 5d | 2018-12-17 | 2018-12-21 | 57FS+28d, 58, 55 | 36d | 4d |
| 60 | 3.4 | **p.b.24 - p.b.30** | 42d | 2018-11-07 | 2019-01-03 |  | 1d |  |
| 61 | 3.4.1 | Realizace základů | 9d | 2018-11-07 | 2018-11-19 | 57 | 1d | 0d |
| 62 | 3.4.2 | Montáž OK na zemi | 9d | 2018-12-07 | 2018-12-19 | 58 | 7d | 0d |
| 63 | 3.4.3 | Postavení OK | 5d | 2018-12-26 | 2019-01-03 | 61FS+28d, 62, 59 | 32d | 6d |
| 64 | 3.5 | **p.b. 31 - p.b.39** | 45d | 2018-11-20 | 2019-01-19 |  | 1d |  |
| 65 | 3.5.1 | Realizace základů | 11d | 2018-11-20 | 2018-12-04 | 61 | 1d | 0d |
| 66 | 3.5.2 | Montáž OK na zemi | 11d | 2018-12-20 | 2019-01-03 | 62 | 7d | 0d |
| 67 | 3.5.3 | Postavení OK | 6d | 2019-01-14 | 2019-01-19 | 65FS+28d, 66, 63 | 26d | 1d |
| 68 | 3.6 | **p.b.40 - p.b.45** | 39d | 2018-12-05 | 2019-01-28 |  | 1d |  |
| 69 | 3.6.1 | Realizace základů | 7d | 2018-12-05 | 2018-12-11 | 65 | 1d | 0d |
| 70 | 3.6.2 | Montáž OK na zemi | 7d | 2019-01-04 | 2019-01-14 | 66 | 7d | 0d |
| 71 | 3.6.3 | Postavení OK | 4d | 2019-01-21 | 2019-01-28 | 69FS+28d, 70, 67 | 25d | 6d |
| 72 | 3.7 | **p.b.46 - p.b.53** | 43d | 2018-12-12 | 2019-02-12 |  | 1d |  |
| 73 | 3.7.1 | Realizace základů | 10d | 2018-12-12 | 2018-12-25 | 69 | 1d | 0d |
| 74 | 3.7.2 | Montáž OK na zemi | 10d | 2019-01-15 | 2019-01-28 | 70 | 7d | 0d |
| 75 | 3.7.3 | Postavení OK | 5d | 2019-02-04 | 2019-02-12 | 73FS+28d, 74, 71 | 19d | 0d |

| ID | WBS | Task | Duration | Start | Finish | Predecessors | Total slack | Free slack | Constraint |
| --- | --- | --- | --- | --- | --- | --- | --- | --- | --- |
| 76 | 3.8 | **p.b.54 - p.b.56** | 35d | 2018-12-26 | 2019-02-14 |  | 1d |  |  |
| 77 | 3.8.1 | Realizace základů | 3d | 2018-12-26 | 2019-01-01 | 73 | 1d | 0d |  |
| 78 | 3.8.2 | Montáž OK na zemi | 3d | 2019-01-29 | 2019-01-31 | 74 | 7d | 0d |  |
| 79 | 3.8.3 | Postavení OK | 2d | 2019-02-13 | 2019-02-14 | 77FS+28d, 78, 75 | 19d | 1d |  |
| 80 | 3.9 | **p.b.57 - p.b.60** | 36d | 2019-01-02 | 2019-02-18 |  | 1d |  |  |
| 81 | 3.9.1 | Realizace základů | 5d | 2019-01-02 | 2019-01-06 | 77 | 1d | 0d |  |
| 82 | 3.9.2 | Montáž OK na zemi | 5d | 2019-02-01 | 2019-02-05 | 78 | 7d | 0d |  |
| 83 | 3.9.3 | Postavení OK | 3d | 2019-02-16 | 2019-02-18 | 81FS+28d, 82, 79 | 18d | 8d |  |
| 84 | 3.10 | **p.b.61 - p.b.69** | 45d | 2019-01-07 | 2019-03-12 |  | 1d |  |  |
| 85 | 3.10.1 | Realizace základů | 11d | 2019-01-07 | 2019-01-21 | 81 | 1d | 0d |  |
| 86 | 3.10.2 | Montáž OK na zemi | 11d | 2019-02-06 | 2019-02-20 | 82 | 7d | 0d |  |
| 87 | 3.10.3 | Postavení OK | 6d | 2019-03-03 | 2019-03-12 | 85FS+28d, 86, 83 | 10d | 5d |  |
| 88 | 3.11 | **p.b.70 - p.b.78** | 45d | 2019-01-22 | 2019-03-27 |  | 1d |  |  |
| 89 | 3.11.1 | Realizace základů | 11d | 2019-01-22 | 2019-02-05 | 85 | 1d | 0d |  |
| 90 | 3.11.2 | Montáž OK na zemi | 11d | 2019-02-25 | 2019-03-11 | 86 | 7d | 0d |  |
| 91 | 3.11.3 | Postavení OK | 6d | 2019-03-18 | 2019-03-27 | 89FS+28d, 90, 87 | 5d | 4d |  |
| 92 | 3.12 | **p.b.79 - p.b.86** | 43d | 2019-02-06 | 2019-04-09 |  | 1d |  |  |
| 93 | 3.12.1 | Realizace základů | 10d | 2019-02-06 | 2019-02-19 | 89 | 1d | 0d |  |
| 94 | 3.12.2 | Montáž OK na zemi | 10d | 2019-03-12 | 2019-03-25 | 90 | 7d | 6d |  |
| 95 | 3.12.3 | Postavení OK | 5d | 2019-04-01 | 2019-04-09 | 93FS+28d, 94, 91 | 1d | 0d |  |
| 96 | 3.13 | **p.b.87 - p.b.95** | 45d | 2018-09-29 | 2018-11-28 |  | 6d |  |  |
| 97 | 3.13.1 | Realizace základů | 11d | 2018-09-29 | 2018-10-13 |  | 6d | 0d |  |
| 98 | 3.13.2 | Montáž OK na zemi | 11d | 2018-11-05 | 2018-11-19 |  | 9d | 0d | start no earlier than 2018-11-05 |
| 99 | 3.13.3 | Postavení OK | 6d | 2018-11-23 | 2018-11-28 | 97FS+28d, 98 | 47d | 4d |  |

| ID | WBS | Task | Duration | Start | Finish | Predecessors | Total slack | Free slack |
| --- | --- | --- | --- | --- | --- | --- | --- | --- |
| 100 | 3.14 | **p.b.96 - p.b.103** | 43d | 2018-10-14 | 2018-12-11 |  | 6d |  |
| 101 | 3.14.1 | Realizace základů | 10d | 2018-10-14 | 2018-10-27 | 97 | 6d | 0d |
| 102 | 3.14.2 | Montáž OK na zemi | 10d | 2018-11-20 | 2018-12-03 | 98 | 9d | 0d |
| 103 | 3.14.3 | Postavení OK | 5d | 2018-12-07 | 2018-12-11 | 101FS+28d, 102, 99 | 43d | 6d |
| 104 | 3.15 | **p.b.104 - p.b.112** | 45d | 2018-10-28 | 2018-12-31 |  | 6d |  |
| 105 | 3.15.1 | Realizace základů | 11d | 2018-10-28 | 2018-11-11 | 101 | 6d | 0d |
| 106 | 3.15.2 | Montáž OK na zemi | 11d | 2018-12-04 | 2018-12-18 | 102 | 9d | 0d |
| 107 | 3.15.3 | Postavení OK | 6d | 2018-12-22 | 2018-12-31 | 105FS+28d, 103, 106 | 37d | 5d |
| 108 | 3.16 | **p.b.113 - p.b.121** | 45d | 2018-11-12 | 2019-01-15 |  | 6d |  |
| 109 | 3.16.1 | Realizace základů | 11d | 2018-11-12 | 2018-11-26 | 105 | 6d | 0d |
| 110 | 3.16.2 | Montáž OK na zemi | 11d | 2018-12-19 | 2019-01-02 | 106 | 9d | 0d |
| 111 | 3.16.3 | Postavení OK | 6d | 2019-01-06 | 2019-01-15 | 109FS+28d, 110, 107 | 32d | 4d |
| 112 | 3.17 | **p.b.122 - p.b.129** | 43d | 2018-11-27 | 2019-01-28 |  | 6d |  |
| 113 | 3.17.1 | Realizace základů | 10d | 2018-11-27 | 2018-12-10 | 109 | 6d | 0d |
| 114 | 3.17.2 | Montáž OK na zemi | 10d | 2019-01-03 | 2019-01-16 | 110 | 9d | 0d |
| 115 | 3.17.3 | Postavení OK | 5d | 2019-01-20 | 2019-01-28 | 113FS+28d, 114, 111 | 28d | 5d |
| 116 | 3.18 | **p.b.130 - p.b.137** | 43d | 2018-12-11 | 2019-02-11 |  | 6d |  |
| 117 | 3.18.1 | Realizace základů | 10d | 2018-12-11 | 2018-12-24 | 113 | 6d | 0d |
| 118 | 3.18.2 | Montáž OK na zemi | 10d | 2019-01-17 | 2019-01-30 | 114 | 9d | 0d |
| 119 | 3.18.3 | Postavení OK | 5d | 2019-02-03 | 2019-02-11 | 117FS+28d, 118, 115 | 23d | 5d |
| 120 | 3.19 | **p.b.138 - p.b.145** | 43d | 2018-12-25 | 2019-02-25 |  | 6d |  |
| 121 | 3.19.1 | Realizace základů | 10d | 2018-12-25 | 2019-01-07 | 117 | 6d | 0d |
| 122 | 3.19.2 | Montáž OK na zemi | 10d | 2019-01-31 | 2019-02-13 | 118 | 9d | 0d |
| 123 | 3.19.3 | Postavení OK | 5d | 2019-02-17 | 2019-02-25 | 121FS+28d, 122, 119 | 18d | 4d |

| ID | WBS | Task | Duration | Start | Finish | Predecessors | Total slack | Free slack |
| --- | --- | --- | --- | --- | --- | --- | --- | --- |
| 124 | 3.20 | **p.b.146 - p.b.152** | 42d | 2019-01-08 | 2019-03-06 |  | 6d |  |
| 125 | 3.20.1 | Realizace základů | 9d | 2019-01-08 | 2019-01-20 | 121 | 6d | 0d |
| 126 | 3.20.2 | Montáž OK na zemi | 9d | 2019-02-14 | 2019-02-26 | 122 | 9d | 0d |
| 127 | 3.20.3 | Postavení OK | 5d | 2019-03-02 | 2019-03-06 | 125FS+28d, 126, 123 | 14d | 7d |
| 128 | 3.21 | **p.b.153 - p.b.162** | 46d | 2019-01-21 | 2019-03-27 |  | 6d |  |
| 129 | 3.21.1 | Realizace základů | 12d | 2019-01-21 | 2019-02-05 | 125 | 6d | 0d |
| 130 | 3.21.2 | Montáž OK na zemi | 12d | 2019-02-27 | 2019-03-14 | 126 | 9d | 0d |
| 131 | 3.21.3 | Postavení OK | 6d | 2019-03-18 | 2019-03-27 | 129FS+28d, 130, 127 | 7d | 1d |
| 132 | 3.22 | **p.b.163 - p.b.168** | 39d | 2019-02-06 | 2019-04-01 |  | 6d |  |
| 133 | 3.22.1 | Realizace základů | 7d | 2019-02-06 | 2019-02-16 | 129 | 6d | 0d |
| 134 | 3.22.2 | Montáž OK na zemi | 7d | 2019-03-15 | 2019-03-25 | 130 | 9d | 3d |
| 135 | 3.22.3 | Postavení OK | 4d | 2019-03-29 | 2019-04-01 | 133FS+28d, 134, 131 | 6d | 0d |
| 136 | 4 | **Montážní práce vodiče** | 31d | 2019-04-02 | 2019-05-14 |  | 1d |  |
| 137 | 4.1 | Portál Jihlava - p.b.2 | 1d | 2019-04-10 | 2019-04-10 | 95 | 1d | 0d |
| 138 | 4.2 | p.b.2 - p.b. 16 | 4d | 2019-04-11 | 2019-04-14 | 137 | 1d | 0d |
| 139 | 4.3 | p.b.16 - p.b.23 | 3d | 2019-04-15 | 2019-04-17 | 138 | 1d | 0d |
| 140 | 4.4 | p.b.23 - p.b.30 | 3d | 2019-04-22 | 2019-04-24 | 139 | 1d | 0d |
| 141 | 4.5 | p.b.30 - p.b.39 | 3d | 2019-04-25 | 2019-04-27 | 140 | 1d | 0d |
| 142 | 4.6 | p.b.39 - p.b.45 | 2d | 2019-04-28 | 2019-04-29 | 141 | 1d | 0d |
| 143 | 4.7 | p.b.45 - p.b.53 | 3d | 2019-04-30 | 2019-05-06 | 142 | 1d | 0d |
| 144 | 4.8 | p.b.53 - p.b.56 | 1d | 2019-05-07 | 2019-05-07 | 143 | 1d | 0d |
| 145 | 4.9 | p.b.56 - p.b.60 | 1d | 2019-05-08 | 2019-05-08 | 144 | 1d | 0d |
| 146 | 4.10 | p.b.60 - p.b.69 | 2d | 2019-05-09 | 2019-05-10 | 145 | 1d | 0d |
| 147 | 4.11 | p.b.69 - p.b.78 | 2d | 2019-05-11 | 2019-05-12 | 146 | 1d | 0d |
| 148 | 4.12 | p.b.78 - p.b.86 | 2d | 2019-05-13 | 2019-05-14 | 147 | 1d | 0d |
| 149 | 4.13 | p.b.86 - p.b.95 | 3d | 2019-04-02 | 2019-04-08 | 135 | 6d | 0d |
| 150 | 4.14 | p.b.95 - p.b.103 | 3d | 2019-04-09 | 2019-04-11 | 149 | 6d | 0d |
| 151 | 4.15 | p.b.103 - p.b.112 | 3d | 2019-04-12 | 2019-04-14 | 150 | 6d | 0d |
| 152 | 4.16 | p.b.112 - p.b.121 | 3d | 2019-04-15 | 2019-04-17 | 151 | 6d | 0d |
| 153 | 4.17 | p.b.121 - p.b.129 | 2d | 2019-04-22 | 2019-04-23 | 152 | 6d | 0d |
| 154 | 4.18 | p.b.129 - p.b.137 | 2d | 2019-04-24 | 2019-04-25 | 153 | 6d | 0d |
| 155 | 4.19 | p.b.137 - p.b.145 | 2d | 2019-04-26 | 2019-04-27 | 154 | 6d | 0d |
| 156 | 4.20 | p.b.145 - p.b.152 | 2d | 2019-04-28 | 2019-04-29 | 155 | 6d | 0d |
| 157 | 4.21 | p.b.152 - p.b.162 | 3d | 2019-04-30 | 2019-05-06 | 156 | 6d | 0d |
| 158 | 4.22 | p.b.162 - p.b.168 | 2d | 2019-05-07 | 2019-05-08 | 157 | 6d | 0d |
| 159 | 4.23 | p.b.168 - portál Telč | 1d | 2019-05-09 | 2019-05-09 | 158 | 6d | 0d |

| ID | WBS | Task | Duration | Start | Finish | Predecessors | Complete | Remaining | Total slack | Free slack | Constraint |
| --- | --- | --- | --- | --- | --- | --- | --- | --- | --- | --- | --- |
| 160 | 5 | **Montážní práce KZL** | 14d | 2019-05-10 | 2019-05-27 |  |  |  | 1d |  |  |
| 161 | 5.1 | portál Jihlava - p.b.30 | 3d | 2019-05-15 | 2019-05-21 | 148 |  |  | 1d | 0d |  |
| 162 | 5.2 | p.b.30 - p.b.60 | 3d | 2019-05-22 | 2019-05-24 | 161 |  |  | 1d | 0d |  |
| 163 | 5.3 | p.b.60 - p.b.86 | 3d | 2019-05-25 | 2019-05-27 | 162 |  |  | 1d |  |  |
| 164 | 5.4 | p.b.86 - p.b.121 | 4d | 2019-05-10 | 2019-05-13 | 159 |  |  | 6d | 0d |  |
| 165 | 5.5 | p.b.121 - p.b.152 | 3d | 2019-05-14 | 2019-05-20 | 164 |  |  | 6d | 0d |  |
| 166 | 5.6 | p.b.152 - portál Telč | 2d | 2019-05-21 | 2019-05-22 | 165 |  |  | 6d |  |  |
| 167 | 6 | **Vypínání vedení** | 209d | 2018-08-13 A | 2019-05-28 |  |  | 208.51d | 0d |  |  |
| 168 | 6.1 | Vedení 110 kV - V520 | 209d | 2018-08-13 | 2019-05-28 | 2SS, 163FF |  |  | 0d |  |  |
| 169 | 6.2 | Vedení 110 kV - V504 | 3d | 2018-08-13 A | 2019-05-15 | 2SS | 33% | 2d | 9d |  |  |
| 170 | 6.3 | Vedení 110 kV - V5530 | 3d | 2018-09-28 | 2019-05-22 | 45SS |  |  | 6d |  |  |
| 171 | 6.4 | Vedení 22 kV a 220 kV | 209d | 2018-08-13 | 2019-05-28 | 2SS |  |  | 0d |  | start no earlier than 2018-08-12 |

Notes:
- 171: Text1: Vedení 22 kV a 220 kV budou zajištěny, délka omezení je uvedena v příloze: "Křižované vedení" v části POV
